# Machine design -Fab academy 2018

Schedule from GanttProject, 2018-04-02 to 2018-04-18.
FabLab CEPT
Week 15 and 16 group work to make machine

## Calendars

- Project calendar: Mon-Sun working.

## Resources

| Resource | Group |
| --- | --- |
| Adhitya | Team member |
| Tanvir |  |
| Gaurav | Team member |
| Rutuja | Team member |

## Schedule

| ID | Task | Type | Duration | Start | Finish | Predecessors | Complete | Resources |
| --- | --- | --- | --- | --- | --- | --- | --- | --- |
| 1 | Idearion and exploration |  | 2d | 2018-04-02 | 2018-04-03 |  | 100% | Adhitya; Tanvir; Gaurav; Rutuja |
| 2 | Design and prototyping |  | 2d | 2018-04-03 | 2018-04-04 |  | 100% | Adhitya; Tanvir; Gaurav; Rutuja |
| 3 | Fianl mechanism selection | milestone | 0d | 2018-04-05 | 2018-04-05 | 2 | 100% | Adhitya; Tanvir; Gaurav; Rutuja |
| 4 | Prototype and test chosen mechanism |  | 1d | 2018-04-05 | 2018-04-05 | 3 | 100% | Adhitya; Tanvir; Gaurav; Rutuja |
| 5 | Prepare BOQ and Procurement |  | 1d | 2018-04-06 | 2018-04-06 | 4 | 100% | Tanvir |
| 6 | CAD design and laser cut |  | 2d | 2018-04-06 | 2018-04-07 | 4 | 100% | Adhitya |
| 7 | 3D CAD design |  | 2d | 2018-04-06 | 2018-04-07 | 4 | 100% | Gaurav |
| 8 | 3D Print - Fabrication |  | 2d | 2018-04-08 | 2018-04-09 | 7 | 100% | Tanvir |
| 9 | Assemble version 1.0 |  | 1d | 2018-04-08 | 2018-04-08 | 6, 7 | 100% | Adhitya; Tanvir; Gaurav; Rutuja |
| 10 | Problem identifcation and design change |  | 1d | 2018-04-09 | 2018-04-09 | 9 | 100% | Adhitya; Tanvir; Gaurav; Rutuja |
| 11 | Design and Laser cut v 2.0 |  | 2d | 2018-04-10 | 2018-04-11 | 10 | 100% | Adhitya |
| 12 | 3D CAD v2.0 |  | 2d | 2018-04-10 | 2018-04-11 | 10 | 100% | Gaurav |
| 13 | 3D Print V2.0 |  | 2d | 2018-04-12 | 2018-04-13 | 12 | 100% | Tanvir |
| 14 | Assemble version 2.0 |  | 2d | 2018-04-14 | 2018-04-15 | 11, 13 | 100% | Adhitya; Tanvir; Gaurav; Rutuja |
| 15 | Controlling of machine and firmware installation |  | 5d | 2018-04-09 | 2018-04-13 | 9 | 100% | Rutuja |
| 16 | Assembly v2.0 Electronics and mechanics |  | 1d | 2018-04-16 | 2018-04-16 | 14, 15 | 100% | Adhitya; Tanvir; Gaurav; Rutuja |
| 17 | Machine Test 2.1 |  | 1d | 2018-04-17 | 2018-04-17 | 16 | 100% | Adhitya; Tanvir; Gaurav; Rutuja |
| 18 | Machine Test 2.5 |  | 1d | 2018-04-18 | 2018-04-18 | 17 | 100% | Adhitya; Tanvir; Gaurav; Rutuja |

Notes:
- 1: -Need to finalize mechanism / -Compare various type of machine / -Analyze material options
